# Proyecto Santa Marta - Bahía Concha

Schedule from MS Project, 2022-07-20 to 2023-04-11, costs in $.
Estabilización de la vía Santa Marta - Bahía Concha usando polímero acrílico, método de estabilización de suelo probado y avalado en diferentes zonas del país y el mundo, escogido por su bajo impacto ambiental, menor tiempo de ejecución y costos inferiores comparados con los métodos convencionales.

## Calendars

- Estándar: Mon-Fri 08:00-12:30, 13:30-17:30; Sat-Sun off.

## Resources

| Resource | Group | Rate |
| --- | --- | --- |
| Patrocinadores | Organización |  |
| Gerente del proyecto | Organización | 15000 |
| Ing. Ambiental | Equipo del proyecto | 8125 |
| Ing. Civil Senior | Equipo del proyecto | 10625 |
| Ing. Civil 1 | Equipo del proyecto | 8125 |
| Ing. Suelos | Equipo del proyecto | 9125 |
| Abogado | Equipo del proyecto | 8125 |
| Contador | Equipo del proyecto | 8125 |
| Técnico Topógrafo | Equipo del proyecto | 7125 |
| Profesional en Seguridad y Salud Ocupacional | Equipo del proyecto | 7125 |
| Cliente | Equipo del proyecto |  |
| Motoniveladora | Maquinaria | 12500 |
| Vibrocompactadora | Maquinaria | 8750 |
| Carro Riego | Maquinaria | 6250 |
| Carro Tanque | Maquinaria | 4625 |
| Obrero | Equipo del proyecto | 6250 |
| Ing. Civil 2 |  | 8125 |
| Administrativo |  |  |
| Auxiliar administrativo |  |  |
| Director de proyecto |  |  |
| Supervisor de obra |  |  |

## Schedule

| ID | WBS | Task | Type | Duration | Start | Finish | Predecessors | Baseline start | Baseline finish | Baseline duration | Total slack | Free slack | Resources | Work | Cost |
| --- | --- | --- | --- | --- | --- | --- | --- | --- | --- | --- | --- | --- | --- | --- | --- |
| 1 | 1 | **INICIO** |  | 0d | 2022-07-20 | 2022-07-20 |  | 2021-07-20 | 2021-07-20 | 0d | 0d |  |  |  |  |
| 2 | 1.1 | Inicio del proyecto | milestone | 0d | 2022-07-20 | 2022-07-20 |  | 2021-07-20 | 2021-07-20 | 0d | 0d |  |  |  |  |
| 3 | 2 | **ESTUDIOS Y DISEÑOS** |  | 67.24d | 2022-07-20 | 2022-10-17 |  | 2021-07-21 | 2021-09-20 | 45d | 0d |  |  | 527.77h | 3,924,000 |
| 4 | 2.1 | Inicio estudios y diseños | milestone | 0d | 2022-07-20 | 2022-07-20 | 2 |  |  |  | 0d |  |  |  |  |
| 5 | 2.2 | **Planos topográficos** |  | 22d | 2022-07-20 | 2022-08-17 |  | 2021-07-21 | 2021-08-11 | 17d | 11.24d |  |  | 100.8h | 723,000 |
| 6 | 2.2.1 | Trazado y replanteo |  | 10d | 2022-07-20 | 2022-08-02 |  |  |  |  | 191.24d |  | Técnico Topógrafo [50%] | 16h | 114,000 |
| 7 | 2.2.2 | Realizar los planos topográficos |  | 20d | 2022-07-20 | 2022-08-15 | 4 | 2021-07-21 | 2021-08-10 | 15d | 11.24d | 0d | Técnico Topógrafo [50%] | 80h | 570,000 |
| 8 | 2.2.3 | Revisar y aprobar planos topográficos |  | 2d | 2022-08-15 | 2022-08-17 | 7 | 2021-08-10 | 2021-08-11 | 2d | 11.24d |  | Ing. Civil 1 [30%] | 4.8h | 39,000 |
| 9 | 2.3 | **Estudio de mercado** |  | 34d | 2022-09-01 | 2022-10-17 |  | 2021-08-10 | 2021-09-20 | 30d | 0d |  |  | 102.17h |  |
| 10 | 2.3.1 | Realizar el estudio de mercado |  | 30d | 2022-09-01 | 2022-10-11 | 17, 8, 14, 20 | 2021-08-10 | 2021-08-31 | 15d | 0d |  | Administrativo [50%] | 62.17h |  |
| 11 | 2.3.2 | Revisar y aprobar el estudio de mercado |  | 4d | 2022-10-11 | 2022-10-17 | 10 | 2021-09-09 | 2021-09-20 | 2d | 0d |  | Administrativo; Director de proyecto [20%] | 40h |  |
| 12 | 2.4 | **Estudios técnicos** |  | 12d | 2022-07-20 | 2022-08-04 |  | 2021-07-21 | 2021-08-05 | 12d | 21.24d |  |  | 84.8h | 701,000 |
| 13 | 2.4.1 | Realizar los estudios técnicos |  | 10d | 2022-07-20 | 2022-08-02 | 4 | 2021-07-21 | 2021-08-03 | 10d | 21.24d | 0d | Ing. Civil 1 | 80h | 650,000 |
| 14 | 2.4.2 | Revisar y aprobar el estudio técnico |  | 2d | 2022-08-02 | 2022-08-04 | 13 | 2021-08-03 | 2021-08-05 | 2d | 21.24d |  | Ing. Civil Senior [30%] | 4.8h | 51,000 |
| 15 | 2.5 | **Estudios ambientales** |  | 31.98d | 2022-07-20 | 2022-08-31 |  | 2021-07-21 | 2021-09-02 | 31.98d | 1.19d |  |  | 120h | 1,250,000 |
| 16 | 2.5.1 | Investigar los posibles impactos ambientales |  | 10d | 2022-07-20 | 2022-08-02 | 4 | 2021-07-21 | 2021-08-03 | 10d | 1.19d | 0d | Ing. Ambiental | 80h | 650,000 |
| 17 | 2.5.2 | Revisar y aprobar el estudio ambiental |  | 2d | 2022-08-02 | 2022-08-31 | 16 | 2021-08-03 | 2021-09-02 | 2d | 1.26d |  | Gerente del proyecto | 40h | 600,000 |
| 18 | 2.6 | **Estudio político y legal** |  | 67.24d | 2022-07-20 | 2022-10-17 |  | 2021-07-21 | 2021-09-09 | 37.33d | 0d |  |  | 120h | 1,250,000 |
| 19 | 2.6.1 | Realizar el estudio político y legal |  | 5d | 2022-07-20 | 2022-07-26 | 4 | 2021-07-21 | 2021-08-03 | 10d | 0d |  | Abogado | 80h | 650,000 |
| 20 | 2.6.2 | Revisar y aprobar el estudio |  | 2d | 2022-08-26 | 2022-09-01 | 19 | 2021-09-02 | 2021-09-09 | 2d | 0d |  | Gerente del proyecto | 40h | 600,000 |
| 21 | 2.6.3 | Fin de estudios y diseños | milestone | 0d | 2022-10-17 | 2022-10-17 | 11 |  |  |  | 0d |  | Director de proyecto; Gerente del proyecto |  |  |
| 22 | 3 | **LICENCIAS Y PERMISOS** |  | 27d | 2022-10-17 | 2022-11-21 |  | 2021-08-31 | 2021-09-27 | 20d | 0d |  |  | 72h | 585,000 |
| 23 | 3.1 | Inicio de licencias y permisos | milestone | 0d | 2022-10-17 | 2022-10-17 | 21 |  |  |  | 0d |  |  |  |  |
| 24 | 3.2 | **Licencias ambientales** |  | 7d | 2022-10-17 | 2022-10-25 |  | 2021-09-13 | 2021-09-22 | 7d | 0d |  |  | 56h | 455,000 |
| 25 | 3.2.1 | Verificar licencias ambientales |  | 7d | 2022-10-17 | 2022-10-25 | 23 | 2021-09-13 | 2021-09-22 | 7d | 0d |  | Ing. Ambiental | 56h | 455,000 |

| ID | WBS | Task | Type | Duration | Start | Finish | Predecessors | Baseline start | Baseline finish | Baseline duration | Total slack | Free slack | Resources | Work | Cost | Baseline cost |
| --- | --- | --- | --- | --- | --- | --- | --- | --- | --- | --- | --- | --- | --- | --- | --- | --- |
| 26 | 3.3 | **Uso de zona de vía** |  | 20d | 2022-10-25 | 2022-11-21 |  | 2021-08-31 | 2021-09-27 | 20d | 0d |  |  | 16h | 130,000 |  |
| 27 | 3.3.1 | Expedir el permiso para uso de zona de vía |  | 20d | 2022-10-25 | 2022-11-21 | 25 | 2021-08-31 | 2021-09-27 | 20d | 0d |  | Ing. Civil 1 [10%] | 16h | 130,000 |  |
| 28 | 3.3.2 | Fin de licencias y permisos | milestone | 0d | 2022-11-21 | 2022-11-21 | 51, 27 |  |  |  | 0d |  |  |  |  |  |
| 29 | 4 | **CONSTRUCCIÓN** |  | 100.01d | 2022-11-21 | 2023-03-31 |  | 2021-09-13 | 2021-12-23 | 72.75d | 0d |  |  | 1528h | 10,503,945.7 | 1,750,226.24 |
| 30 | 4.1 | Inicio de ejecucion de obra | milestone | 0d | 2022-11-21 | 2022-11-21 | 28 |  |  |  | 0d |  |  |  |  |  |
| 31 | 4.2 | **Vía estabilizada con polímeros** |  | 100.01d | 2022-11-21 | 2023-03-31 |  | 2021-09-13 | 2021-12-23 | 72.75d | 0d |  |  | 1528h | 10,503,945.7 | 1,750,226.24 |
| 32 | 4.2.1 | **Vía escarificada** |  | 35d | 2022-11-21 | 2023-01-05 |  | 2021-09-13 | 2021-10-15 | 25d | 0d |  |  | 440h | 3,370,000 | 500,000 |
| 33 | 4.2.1.1 | Escarificación del suelo con motoniveladora |  | 30d | 2022-11-21 | 2022-12-29 | 30 | 2021-09-13 | 2021-10-08 | 20d | 0d |  | Motoniveladora; Obrero; Profesional en Seguridad y Salud Ocupacional; Ing. Civil 2 | 400h | 3,370,000 | 500,000 |
| 34 | 4.2.1.2 | Correción y aprobación de la escarificación |  | 5d | 2022-12-29 | 2023-01-05 | 33 | 2021-10-08 | 2021-10-15 | 5d | 0d |  | Supervisor de obra | 40h |  |  |
| 35 | 4.2.2 | **Vía regada con polímeros** |  | 30d | 2023-01-05 | 2023-02-14 |  | 2021-10-15 | 2021-11-16 | 20.69d | 0d |  |  | 448h | 2,867,769.23 | 588,461.54 |
| 36 | 4.2.2.1 | Riego de polímero acrílico acuoso |  | 25d | 2023-01-05 | 2023-02-08 | 34 | 2021-10-15 | 2021-11-08 | 15.69d | 0d |  | Carro Riego; Obrero; Profesional en Seguridad y Salud Ocupacional; Ing. Civil 2 | 408h | 2,867,769.23 | 588,461.54 |
| 37 | 4.2.2.2 | Correción y aprobación del riego de polímeros |  | 5d | 2023-02-08 | 2023-02-14 | 36 | 2021-11-08 | 2021-11-16 | 5d | 0d |  | Supervisor de obra | 40h |  |  |
| 38 | 4.2.3 | **Vía compactada** |  | 35.01d | 2023-02-14 | 2023-03-31 |  | 2021-11-16 | 2021-12-23 | 27d | 0d |  |  | 640h | 4,266,176.47 | 661,764.71 |
| 39 | 4.2.3.1 | Compactación de la vía con vibrocompactadora |  | 29.99d | 2023-02-14 | 2023-03-27 | 37 | 2021-11-16 | 2021-12-16 | 22.06d | 0d |  | Obrero; Vibrocompactadora; Profesional en Seguridad y Salud Ocupacional; Carro Tanque; Ing. Civil 2 | 600h | 4,266,176.47 | 661,764.71 |
| 40 | 4.2.3.2 | Corrección y aprobación de la compactación |  | 5d | 2023-03-27 | 2023-03-31 | 39 | 2021-12-16 | 2021-12-23 | 5d | 0d |  | Supervisor de obra | 40h |  |  |
| 41 | 4.2.3.3 | Fin de ejecucion de obra | milestone | 0d | 2023-03-31 | 2023-03-31 | 40 |  |  |  | 0d |  |  |  |  |  |
| 42 | 5 | **DIRECCIÓN DEL PROYECTO** |  | 201.24d | 2022-07-20 | 2023-04-11 |  | 2021-07-21 | 2022-01-21 | 135.75d | 0d |  |  | 616h | 3,757,410.64 |  |
| 43 | 5.1 | Inicio de entrega del proyecto | milestone | 0d | 2023-03-31 | 2023-03-31 | 41 |  |  |  | 0d |  |  |  |  |  |
| 44 | 5.2 | **Actas de entrega** |  | 6d | 2023-03-31 | 2023-04-10 |  | 2021-12-23 | 2022-01-07 | 12d | 0d |  |  | 112h | 1,014,000 |  |
| 45 | 5.2.1 | Revisión de todos los estudios y diseños del proyecto |  | 5d | 2023-03-31 | 2023-04-07 | 43 | 2021-12-23 | 2022-01-05 | 10d | 0d |  | Ing. Civil Senior | 80h | 850,000 |  |
| 46 | 5.2.2 | Socialización de los actas de entrega |  | 1d | 2023-04-07 | 2023-04-10 | 45 | 2022-01-05 | 2022-01-07 | 2d | 0d |  | Gerente del proyecto [50%]; Ing. Civil Senior [50%]; Patrocinadores; Director de proyecto [20%] | 32h | 164,000 |  |
| 47 | 5.3 | **Acta de constitución del proyecto** |  | 6d | 2022-07-20 | 2022-07-27 |  | 2021-07-21 | 2021-08-05 | 12.62d | 195.24d |  |  | 112h | 144,905.66 |  |
| 48 | 5.3.1 | Elaboración del acta de constitución del proyecto |  | 5d | 2022-07-20 | 2022-07-26 | 2 | 2021-07-21 | 2021-08-03 | 10d | 195.24d | 0d | Administrativo | 80h |  |  |
| 49 | 5.3.2 | Socialización del acta de constitución del proyecto |  | 1d | 2022-07-26 | 2022-07-27 | 48 | 2021-08-03 | 2021-08-05 | 2.62d | 195.24d |  | Gerente del proyecto [20%]; Patrocinadores [20%]; Director de proyecto [20%] | 32h | 144,905.66 |  |

| ID | WBS | Task | Type | Duration | Start | Finish | Predecessors | Baseline start | Baseline finish | Baseline duration | Total slack | Free slack | Resources | Work | Cost |
| --- | --- | --- | --- | --- | --- | --- | --- | --- | --- | --- | --- | --- | --- | --- | --- |
| 50 | 5.4 | **Plan de dirección del proyecto** |  | 11d | 2022-10-25 | 2022-11-09 |  | 2021-08-31 | 2021-09-15 | 12d | 10d |  |  | 272h | 2,150,000 |
| 51 | 5.4.1 | Elaboración del Plan de dirección del proyecto |  | 10d | 2022-10-25 | 2022-11-08 | 25 | 2021-08-31 | 2021-09-13 | 10d | 10d | 0d | Abogado [50%]; Contador [50%]; Ing. Ambiental [50%]; Ing. Suelos [50%]; Ing. Civil 2 | 240h | 1,990,000 |
| 52 | 5.4.2 | Socialización del Plan de dirección del proyecto |  | 1d | 2022-11-08 | 2022-11-09 | 51 | 2021-09-13 | 2021-09-15 | 2d | 116.01d |  | Gerente del proyecto; Patrocinadores; Director de proyecto [20%] | 32h | 160,000 |
| 53 | 5.5 | **Acta de finalización firmada por las partes interesadas** |  | 1d | 2023-04-10 | 2023-04-11 |  | 2022-01-07 | 2022-01-20 | 10d | 0d |  |  | 120h | 448,504.98 |
| 54 | 5.5.1 | Presentación y aprobación del acta de finalización por las partes interesadas |  | 1d | 2023-04-10 | 2023-04-11 | 46 | 2022-01-07 | 2022-01-21 | 11d | 0d |  | Gerente del proyecto; Patrocinadores; Director de proyecto [20%] | 120h | 448,504.98 |
| 55 | 6 | **CIERRE** |  | 0d | 2023-04-11 | 2023-04-11 |  | 2022-01-21 | 2022-01-21 | 0d | 0d |  |  |  |  |
| 56 | 6.1 | Fin del proyecto | milestone | 0d | 2023-04-11 | 2023-04-11 | 54 | 2022-01-21 | 2022-01-21 | 0d | 0d |  |  |  |  |
